# LACRAMARCA - LICITACIÓN

Schedule from Primavera P6, 2023-10-18 to 2024-05-04, data date 2023-09-25.

## Calendars

- Lacramarca: Mon-Fri 07:00-13:00, 14:00-17:00; Sat 07:00-13:00; Sun off. Exceptions (off unless hours are given): 2023-11-01, 2023-12-08 to 2023-12-09, 2023-12-25, 2024-01-01, 2024-03-28 to 2024-03-29, 2024-04-06 08:00-16:00, 2024-05-01.
- DÍAS CALENDARIOS: Mon-Sun 08:00-16:00.

## Resources

| Resource | Group | Notes |
| --- | --- | --- |
| Camión grua | labor | ï»¿ |
| CAPATAZ | labor | ï»¿ |
| OPERARIO | labor | ï»¿ |
| PEON | labor | ï»¿ |
| Camión Cisterna 4x2 400 HP Agua (5000 gal) | labor | ï»¿ |
| Camión Volquete (15 m3) | labor | ï»¿ |
| CUADRADOR/VIGÍA | labor | ï»¿ |
| Excavadora Sobre Oruga 260 HP | labor | ï»¿ |
| Motoniveladora 185 HP | labor | ï»¿ |
| OFICIAL | labor | ï»¿ |
| Retroexcavador 58 HP | labor | ï»¿ |
| Rodillo Vib. Liso Autopropulsado 135 HP 12 TM | labor | ï»¿ |
| Tractor S/Orugas (D6T) - 180 HP | labor | ï»¿ |
| Camión baranda 3 TON | labor | ï»¿ |
| Camión Plataforma 4x2 122 HP | labor | ï»¿ |
| Cargador Frontal 195 HP | labor | ï»¿ |
| CARGADOR SOBRE LLANTAS DE 200-250 HP | labor | ï»¿ |
| AYUDANTE DE NIVELADOR | labor | ï»¿ |
| AYUDANTE DE TOPOGRAFO | labor | ï»¿ |
| TOPOGRAFO | labor | ï»¿ |
| OP. NIVELADOR | labor | ï»¿ |

## Schedule

| ID | WBS | Activity | Duration | Start | Finish | Predecessors | Planned start | Planned finish | Total float | Free float | Constraint | Resources |
| --- | --- | --- | --- | --- | --- | --- | --- | --- | --- | --- | --- | --- |
|  | 2 | **CONSTRUCCIÓN SUB PROYECTO A3 - RÍO LACRAMARCA** |  | 2023-10-18 | 2024-05-04 |  |  |  |  |  |  |  |
|  | 1 | **DEFENSAS RIBEREÑAS** |  | 2023-10-18 | 2024-05-03 |  |  |  |  |  |  |  |
|  | 1 | **OBRAS PRELIMINARES** |  | 2023-10-23 | 2023-11-04 |  |  |  |  |  |  |  |
| 1.01.02 |  | INSTALACIONES PROVISIONALES PARA LA OBRA | 10d | 2023-10-23 | 2023-11-04 |  |  |  | 136.22d | 0d |  | Camión grua [64 h]; CAPATAZ [80 h]; OPERARIO [480 h]; PEON [640 h] |
| 1.01.03 |  | MANTENIMIENTO DE TRÁNSITO Y SEGURIDAD VIAL | 10d | 2023-10-23 | 2023-11-04 | 1.01.02 SS |  |  | 140.22d |  |  | Camión Cisterna 4x2 400 HP Agua (5000 gal) [1659.4 h]; Camión Volquete (15 m3) [737.6 h]; CAPATAZ [1860.16 h]; CUADRADOR/VIGÍA [3720.32 h]; Excavadora Sobre Oruga 260 HP [368.8 h]; Motoniveladora 185 HP [1075.5 h]; OFICIAL [368.8 h]; OPERARIO [368.8 h]; PEON [3720.32 h]; Retroexcavador 58 HP [717 h]; Rodillo Vib. Liso Autopropulsado 135 HP 12 TM [1075.5 h]; Tractor S/Orugas (D6T) - 180 HP [368.8 h] |
|  | 2 | **TRABAJOS PRELIMINARES** |  | 2023-10-18 | 2023-11-03 |  |  |  |  |  |  |  |
| 01.02.01 |  | MOVILIZACION Y DESMOVILIZACION DE EQUIPOS | 13.33d | 2023-10-18 | 2023-11-03 |  | 2023-10-19 | 2023-11-06 | 0d |  | start on or after 2023-10-19 | Camión baranda 3 TON [2 h]; Camión Cisterna 4x2 400 HP Agua (5000 gal) [3 h]; Camión grua [1 h]; Camión Plataforma 4x2 122 HP [1 h]; Camión Volquete (15 m3) [30 h]; Cargador Frontal 195 HP [2 h]; CARGADOR SOBRE LLANTAS DE 200-250 HP [2 h]; Excavadora Sobre Oruga 260 HP [10 h]; Motoniveladora 185 HP [4 h]; Retroexcavador 58 HP [3 h]; Rodillo Vib. Liso Autopropulsado 135 HP 12 TM [4 h]; Tractor S/Orugas (D6T) - 180 HP [5 h] |
|  | 3 | **MEJORAMIENTO DE VÍAS EXISTENTES** |  | 2023-10-23 | 2023-11-09 |  |  |  |  |  |  |  |
|  | 1 | **MOVIMIENTO DE TIERRAS** |  | 2023-10-23 | 2023-10-28 |  |  |  |  |  |  |  |
| 1.03.01.01 |  | ROCE Y LIMPIEZA DE MALEZA | 5.33d | 2023-10-23 | 2023-10-28 | 01.02.01 SS+4d |  |  | 0d |  |  | AYUDANTE DE NIVELADOR [1428.96 h]; AYUDANTE DE TOPOGRAFO [2857.92 h]; Camión baranda 3 TON [14.93 h]; CAPATAZ [7.46 h]; CUADRADOR/VIGÍA [14.93 h]; PEON [29.86 h]; Retroexcavador 58 HP [7.46 h]; TOPOGRAFO [2857.92 h]; Tractor S/Orugas (D6T) - 180 HP [7.46 h]; OP. NIVELADOR [1428.96 h] |
|  | 2 | **REPOSICIÓN DE ESTRUCTURAS** |  | 2023-11-06 | 2023-11-08 |  |  |  |  |  |  |  |
| 1.03.02.01 |  | DEMOLICIÓN DE ESTRUCTURAS EXISTENTES | 1d | 2023-11-06 | 2023-11-06 | 1.01.02 |  |  | 136.22d | 0d |  | Camión Volquete (15 m3) [7.47 h]; CAPATAZ [0.75 h]; OPERARIO [14.93 h]; PEON [14.93 h]; Retroexcavador 58 HP [7.47 h] |
| 1.03.02.02 |  | REPOSICIÓN DE PASE DE AGUA TUBO HDPE Ø=18" | 1d | 2023-11-07 | 2023-11-07 | 1.03.02.01 |  |  | 137.22d | 0d |  | CAPATAZ [0.4 h]; OPERARIO [8 h]; PEON [16 h]; Retroexcavador 58 HP [4 h] |
| 1.03.02.03 |  | REPOSICIÓN DE PASE DE AGUA TUBO HDPE Ø=36" | 1d | 2023-11-07 | 2023-11-07 | 1.03.02.02 SS |  |  | 137.22d | 0d |  | CAPATAZ [0.5 h]; OPERARIO [10 h]; PEON [20 h]; Retroexcavador 58 HP [5 h] |
| 1.03.02.04 |  | SUMINISTRO Y MONTAJE DE PANELES DE C°A° 1.6mx1.0mx0.20m EN PASE DE AGUA | 1d | 2023-11-08 | 2023-11-08 | 1.03.02.03 |  |  | 137.22d | 0d |  | CAPATAZ [0.28 h]; PEON [5.6 h] |
| 1.03.02.05 |  | SUMINISTRO Y MONTAJE DE PANELES DE C°A° 2.20mx1.0mx0.20m EN PASE DE AGUA | 1d | 2023-11-08 | 2023-11-08 | 1.03.02.04 SS |  |  | 137.22d |  |  | CAPATAZ [0.2 h]; PEON [4 h] |
|  | 3 | **CABEZAL DE ENTRADA Y SALIDA** |  | 2023-11-07 | 2023-11-09 |  |  |  |  |  |  |  |
| 1.03.03.02 |  | ENCOFRADO Y DESENCOFRADO RECTO | 2d | 2023-11-07 | 2023-11-08 | 1.03.02.01 SS+1d |  |  | 136.22d | 0d |  | CAPATAZ [7.06 h]; OPERARIO [14.12 h]; PEON [14.12 h] |
| 1.03.03.01 |  | CONCRETOS | 1d | 2023-11-09 | 2023-11-09 | 1.03.03.02 |  |  | 136.22d |  |  | CAPATAZ [0.32 h]; OFICIAL [1.61 h]; OPERARIO [3.22 h]; PEON [16.11 h] |
|  | 4 | **DESCOLMATACIÓN DE CAUCE y OBRAS AUXILIARES** |  | 2023-10-30 | 2024-02-26 |  |  |  |  |  |  |  |
| 1.04.01 |  | DESBROCE Y LIMPIEZA EN ZONA NO BOSCOSA | 37d | 2023-10-30 | 2023-12-16 | 1.03.01.01 |  |  | 6.24d | 0d |  | Camión Volquete (15 m3) [304.61 h]; CUADRADOR/VIGÍA [304.61 h]; Excavadora Sobre Oruga 260 HP [304.61 h]; OPERARIO [913.84 h]; PEON [1827.68 h]; Tractor S/Orugas (D6T) - 180 HP [152.31 h] |
| 1.04.02 |  | DESCOLMATACIÓN DE CAUCE NATURAL DEL RÍO LACRAMARCA | 73.67d | 2023-11-02 | 2024-02-05 | 1.04.01 SS+2d |  |  | 52.22d | 0d |  | CAPATAZ [58.09 h]; CUADRADOR/VIGÍA [615.8 h]; Excavadora Sobre Oruga 260 HP [615.8 h]; PEON [1243.21 h]; Tractor S/Orugas (D6T) - 180 HP [615.8 h] |
| 1.04.03 |  | CONFORMACIÓN DE DESVIO EN CAUCE DE RÍO | 55d | 2023-11-02 | 2024-01-12 | 1.04.02 SS |  |  | 52.22d | 0d |  | CAPATAZ [457.34 h]; CUADRADOR/VIGÍA [457.34 h]; Excavadora Sobre Oruga 260 HP [228.67 h]; OPERARIO [457.34 h]; PEON [914.67 h]; Tractor S/Orugas (D6T) - 180 HP [457.34 h] |
| 1.04.04 |  | RELLENO NO ESTRUCTURAL CON MATERIAL PROPIO | 90.67d | 2023-11-02 | 2024-02-26 | 1.04.03 SS |  |  | 52.22d |  |  | Camión Cisterna 4x2 400 HP Agua (5000 gal) [154.92 h]; CAPATAZ [74.59 h]; CUADRADOR/VIGÍA [763.11 h]; Motoniveladora 185 HP [154.92 h]; OPERARIO [763.11 h]; PEON [3058.19 h]; Rodillo Vib. Liso Autopropulsado 135 HP 12 TM [154.92 h]; Tractor S/Orugas (D6T) - 180 HP [763.11 h] |

| ID | WBS | Activity | Duration | Start | Finish | Predecessors | Total float | Free float | Resources |
| --- | --- | --- | --- | --- | --- | --- | --- | --- | --- |
|  | 5 | **DIQUES DE TIERRA COMPACTADA CON ENROCADO** |  | 2023-10-23 | 2024-05-03 |  |  |  |  |
|  | 1 | **DIQUE DE TIERRA COMPACTADA A3-D-01** |  | 2023-10-30 | 2024-01-04 |  |  |  |  |
| 1.05.01.01 |  | EXCAVACIÓN EN TERRENO NATURAL CON EQUIPO | 2d | 2023-10-30 | 2023-10-31 | 1.04.01 SS | 6.24d | 0d | Camión Volquete (15 m3) [2976.35 h]; CAPATAZ [270.18 h]; CARGADOR SOBRE LLANTAS DE 200-250 HP [2643.39 h]; Excavadora Sobre Oruga 260 HP [225.02 h]; PEON [57.97 h]; Tractor S/Orugas (D6T) - 180 HP [28.99 h] |
| 1.05.01.02 |  | EXCAVACIÓN DE UÑA CON EQUIPO | 2d | 2023-10-30 | 2023-10-31 | 1.05.01.01 SS | 94.56d | 0d | CAPATAZ [26.51 h]; Excavadora Sobre Oruga 260 HP [53.24 h]; PEON [53.24 h] |
| 1.05.01.03 |  | PERFILADO Y COMPACTACIÓN EN ZONA DE CORTE | 5.67d | 2023-11-02 | 2023-11-08 | 1.05.01.01, 1.05.01.02 | 94.56d | 0d | Camión Cisterna 4x2 400 HP Agua (5000 gal) [44.77 h]; CAPATAZ [22.38 h]; Motoniveladora 185 HP [44.77 h]; OFICIAL [44.77 h]; PEON [44.77 h]; Rodillo Vib. Liso Autopropulsado 135 HP 12 TM [44.77 h] |
| 1.05.01.09 |  | PREPARACIÓN DE FUNDACIÓN DE CUERPO DE DIQUE | 2d | 2023-11-09 | 2023-11-10 | 1.05.01.03 | 94.56d | 0d | CAPATAZ [1.02 h]; Excavadora Sobre Oruga 260 HP [2.55 h]; Motoniveladora 185 HP [10.22 h]; OPERARIO [10.22 h]; PEON [20.43 h]; Rodillo Vib. Liso Autopropulsado 135 HP 12 TM [10.22 h] |
| 1.05.01.04 |  | CONFORMACIÓN DE CUERPO DE DIQUE CON MATERIAL PROPIO | 5.67d | 2023-11-11 | 2023-11-17 | 1.05.01.09 | 94.56d | 0d | Camión Cisterna 4x2 400 HP Agua (5000 gal) [43.77 h]; CAPATAZ [43.77 h]; Excavadora Sobre Oruga 260 HP [43.77 h]; Motoniveladora 185 HP [43.77 h]; OFICIAL [43.77 h]; OPERARIO [43.77 h]; PEON [174.9 h]; Rodillo Vib. Liso Autopropulsado 135 HP 12 TM [43.77 h] |
| 1.05.01.06 |  | GEOTEXTIL NO TEJIDO 400 G/M2, INC. COLOCACIÓN | 14d | 2023-11-18 | 2023-12-05 | 1.05.01.04 | 94.56d | 0d | CAPATAZ [10.76 h]; OPERARIO [107.64 h]; PEON [430.54 h] |
| 1.05.01.07 |  | COLOCACION Y ACOMODO DE ROCA EN UÑA DE DIQUE | 8.67d | 2023-12-06 | 2023-12-18 | 1.05.01.06 | 94.56d | 0d | Camión Volquete (15 m3) [2976.35 h]; CAPATAZ [530.38 h]; CUADRADOR/VIGÍA [2643.4 h]; Excavadora Sobre Oruga 260 HP [432.79 h]; OPERARIO [265.75 h]; PEON [1594.27 h] |
| 1.05.01.08 |  | COLOCACION Y ACOMODO DE ROCA EN TALUD DE DIQUE | 15.33d | 2023-12-11 | 2023-12-29 | 1.05.01.07 SS+2d | 94.56d | 0d | Camión Volquete (15 m3) [2976.35 h]; CAPATAZ [730.3 h]; CUADRADOR/VIGÍA [2643.4 h]; Excavadora Sobre Oruga 260 HP [632.72 h]; OPERARIO [465.67 h]; PEON [4657.71 h] |
| 1.05.01.05 |  | CONFORMACIÓN DE CORONA DE DIQUE CON MATERIAL PROPIO | 3.67d | 2023-12-30 | 2024-01-04 | 1.05.01.08 | 94.56d |  | Camión Cisterna 4x2 400 HP Agua (5000 gal) [28.59 h]; CAPATAZ [28.59 h]; Excavadora Sobre Oruga 260 HP [28.59 h]; Motoniveladora 185 HP [28.59 h]; OFICIAL [28.59 h]; OPERARIO [28.59 h]; PEON [114.26 h]; Rodillo Vib. Liso Autopropulsado 135 HP 12 TM [28.59 h] |
|  | 2 | **DIQUE DE TIERRA COMPACTADA A3-D-02** |  | 2023-10-23 | 2024-05-03 |  |  |  |  |
| 1.06.02.01 |  | EXCAVACIÓN EN TERRENO NATURAL CON EQUIPO | 19.67d | 2023-10-23 | 2023-11-16 | 1.03.01.01 SS | 0d |  | Camión Volquete (15 m3) [2976.35 h]; CAPATAZ [312.59 h]; CUADRADOR/VIGÍA [2643.4 h]; Excavadora Sobre Oruga 260 HP [667.94 h]; PEON [500.89 h]; Tractor S/Orugas (D6T) - 180 HP [250.44 h] |
| 1.06.02.02 |  | EXCAVACIÓN DE UÑA CON EQUIPO | 18.67d | 2023-10-25 | 2023-11-17 | 1.06.02.01 SS+2d | 0d |  | CAPATAZ [190.6 h]; Excavadora Sobre Oruga 260 HP [382.86 h]; PEON [382.86 h] |
| 1.06.02.03 |  | PERFILADO Y COMPACTACIÓN EN ZONA DE CORTE | 32.67d | 2023-10-28 | 2023-12-11 | 1.06.02.02 SS+3d | 0d |  | Camión Cisterna 4x2 400 HP Agua (5000 gal) [278.77 h]; CAPATAZ [139.39 h]; Motoniveladora 185 HP [278.77 h]; OFICIAL [278.77 h]; PEON [278.77 h]; Rodillo Vib. Liso Autopropulsado 135 HP 12 TM [278.77 h] |
| 1.06.02.09 |  | PREPARACIÓN DE FUNDACIÓN DE CUERPO DE DIQUE | 5.67d | 2023-12-12 | 2023-12-18 | 1.06.02.03 | 0d |  | CAPATAZ [4.15 h]; Excavadora Sobre Oruga 260 HP [10.38 h]; Motoniveladora 185 HP [41.53 h]; OPERARIO [41.53 h]; PEON [83.05 h]; Rodillo Vib. Liso Autopropulsado 135 HP 12 TM [41.53 h] |
| 1.06.02.04 |  | CONFORMACIÓN DE CUERPO DE DIQUE CON MATERIAL PROPIO | 22.67d | 2023-12-19 | 2024-01-17 | 1.06.02.09 | 0d |  | Camión Cisterna 4x2 400 HP Agua (5000 gal) [185.32 h]; CAPATAZ [185.32 h]; Excavadora Sobre Oruga 260 HP [185.32 h]; Motoniveladora 185 HP [185.32 h]; OFICIAL [185.32 h]; OPERARIO [185.32 h]; PEON [740.59 h]; Rodillo Vib. Liso Autopropulsado 135 HP 12 TM [185.32 h] |
| 1.06.02.06 |  | GEOTEXTIL NO TEJIDO 400 G/M2, INC. COLOCACIÓN | 57.33d | 2023-12-26 | 2024-03-06 | 1.06.02.04 SS+5d | 0d |  | CAPATAZ [48.73 h]; OPERARIO [487.29 h]; PEON [1949.15 h] |
| 1.06.02.07 |  | COLOCACION Y ACOMODO DE ROCA EN UÑA DE DIQUE | 54.33d | 2023-12-29 | 2024-03-06 | 1.06.02.06 SS+3d | 0d |  | Camión Volquete (15 m3) [2976.35 h]; CAPATAZ [2175.61 h]; CUADRADOR/VIGÍA [2643.4 h]; Excavadora Sobre Oruga 260 HP [167.05 h]; OPERARIO [1910.98 h]; PEON [11464.2 h] |
| 1.06.02.08 |  | COLOCACION Y ACOMODO DE ROCA EN TALUD DE DIQUE | 79.89d | 2023-12-30 | 2024-04-10 | 1.06.02.07 SS+1d | 0d |  | Camión Volquete (15 m3) [2976.35 h]; CAPATAZ [2933.71 h]; CUADRADOR/VIGÍA [2643.4 h]; Excavadora Sobre Oruga 260 HP [167.05 h]; OPERARIO [2669.08 h]; PEON [2669.08 h] |
| 1.06.02.05 |  | CONFORMACIÓN DE CORONA DE DIQUE CON MATERIAL PROPIO | 18d | 2024-04-11 | 2024-05-03 | 1.06.02.08 | 0d |  | Camión Cisterna 4x2 400 HP Agua (5000 gal) [144.43 h]; CAPATAZ [144.43 h]; Excavadora Sobre Oruga 260 HP [144.43 h]; Motoniveladora 185 HP [144.43 h]; OFICIAL [144.43 h]; OPERARIO [144.43 h]; PEON [577.21 h]; Rodillo Vib. Liso Autopropulsado 135 HP 12 TM [144.43 h] |
|  | 3 | **DIQUE DE TIERRA COMPACTADA A3-I-01** |  | 2023-11-02 | 2024-01-02 |  |  |  |  |
| 1.06.03.01 |  | EXCAVACIÓN EN TERRENO NATURAL CON EQUIPO | 8.33d | 2023-11-02 | 2023-11-11 | 1.05.01.01 | 6.24d | 0d | Camión Volquete (15 m3) [2976.35 h]; CAPATAZ [312.59 h]; CUADRADOR/VIGÍA [2643.4 h]; Excavadora Sobre Oruga 260 HP [667.94 h]; PEON [500.89 h]; Tractor S/Orugas (D6T) - 180 HP [250.44 h] |
| 1.06.03.02 |  | EXCAVACIÓN DE UÑA CON EQUIPO | 9.33d | 2023-11-02 | 2023-11-13 | 1.06.03.01 SS | 96.56d | 0d | CAPATAZ [190.6 h]; Excavadora Sobre Oruga 260 HP [382.86 h]; PEON [382.86 h] |
| 1.06.03.03 |  | PERFILADO Y COMPACTACIÓN EN ZONA DE CORTE | 8.33d | 2023-11-04 | 2023-11-14 | 1.06.03.02 SS+2d | 96.56d | 0d | Camión Cisterna 4x2 400 HP Agua (5000 gal) [278.77 h]; CAPATAZ [139.39 h]; Motoniveladora 185 HP [287.77 h]; OFICIAL [278.77 h]; PEON [278.77 h]; Rodillo Vib. Liso Autopropulsado 135 HP 12 TM [278.77 h] |
| 1.06.03.09 |  | PREPARACIÓN DE FUNDACIÓN DE CUERPO DE DIQUE | 2d | 2023-11-15 | 2023-11-16 | 1.06.03.03 | 96.56d | 0d | CAPATAZ [4.15 h]; Excavadora Sobre Oruga 260 HP [10.38 h]; Motoniveladora 185 HP [41.53 h]; OPERARIO [41.53 h]; PEON [83.05 h]; Rodillo Vib. Liso Autopropulsado 135 HP 12 TM [41.53 h] |
| 1.06.03.04 |  | CONFORMACIÓN DE CUERPO DE DIQUE CON MATERIAL PROPIO | 9.33d | 2023-11-17 | 2023-11-28 | 1.06.03.09 | 96.56d | 0d | Camión Cisterna 4x2 400 HP Agua (5000 gal) [185.32 h]; CAPATAZ [185.32 h]; Excavadora Sobre Oruga 260 HP [185.32 h]; Motoniveladora 185 HP [185.32 h]; OFICIAL [185.32 h]; OPERARIO [185.32 h]; PEON [740.59 h]; Rodillo Vib. Liso Autopropulsado 135 HP 12 TM [185.32 h] |
| 1.06.03.06 |  | GEOTEXTIL NO TEJIDO 400 G/M2, INC. COLOCACIÓN | 13d | 2023-11-22 | 2023-12-07 | 1.06.03.04 SS+4d | 96.56d | 0d | CAPATAZ [48.73 h]; OPERARIO [487.29 h]; PEON [1949.15 h] |
| 1.06.03.07 |  | COLOCACION Y ACOMODO DE ROCA EN UÑA DE DIQUE | 10.67d | 2023-11-28 | 2023-12-12 | 1.06.03.06 SS+4.33d | 96.56d | 0d | Camión Volquete (15 m3) [2976.35 h]; CAPATAZ [2175.61 h]; CUADRADOR/VIGÍA [2643.4 h]; Excavadora Sobre Oruga 260 HP [2078.03 h]; OPERARIO [1910.98 h]; PEON [11464.2 h] |
| 1.06.03.08 |  | COLOCACION Y ACOMODO DE ROCA EN TALUD DE DIQUE | 19d | 2023-12-01 | 2023-12-27 | 1.06.03.07 SS+3d | 96.56d | 0d | Camión Volquete (15 m3) [2976.35 h]; CAPATAZ [2933.71 h]; CUADRADOR/VIGÍA [2643.4 h]; Excavadora Sobre Oruga 260 HP [2836.13 h]; OPERARIO [2669.08 h]; PEON [26696.8 h] |
| 1.06.03.05 |  | CONFORMACIÓN DE CORONA DE DIQUE CON MATERIAL PROPIO | 3.67d | 2023-12-28 | 2024-01-02 | 1.06.03.08 | 96.56d |  | Camión Cisterna 4x2 400 HP Agua (5000 gal) [144.43 h]; CAPATAZ [144.43 h]; Excavadora Sobre Oruga 260 HP [144.43 h]; Motoniveladora 185 HP [144.43 h]; OFICIAL [144.43 h]; OPERARIO [144.43 h]; PEON [577.21 h]; Rodillo Vib. Liso Autopropulsado 135 HP 12 TM [144.43 h] |

| ID | WBS | Activity | Duration | Start | Finish | Predecessors | Planned start | Planned finish | Total float | Free float | Calendar | Resources |
| --- | --- | --- | --- | --- | --- | --- | --- | --- | --- | --- | --- | --- |
|  | 4 | **DIQUE DE TIERRA COMPACTADA A3-I-02** |  | 2023-11-13 | 2024-02-17 |  |  |  |  |  |  |  |
| 1.06.04.01 |  | EXCAVACIÓN EN TERRENO NATURAL CON EQUIPO | 22d | 2023-11-13 | 2023-12-11 | 1.06.03.01 |  |  | 6.24d | 0d |  | Camión Volquete (15 m3) [2976.35 h]; CAPATAZ [277.02 h]; CUADRADOR/VIGÍA [2643.4 h]; Excavadora Sobre Oruga 260 HP [296.44 h]; PEON [129.39 h]; Tractor S/Orugas (D6T) - 180 HP [64.69 h] |
| 1.06.04.02 |  | EXCAVACIÓN DE UÑA CON EQUIPO | 23d | 2023-11-13 | 2023-12-12 | 1.06.04.01 SS |  |  | 59.22d | 0d |  | CAPATAZ [25.94 h]; Excavadora Sobre Oruga 260 HP [52.11 h]; PEON [52.11 h] |
| 1.06.04.03 |  | PERFILADO Y COMPACTACIÓN EN ZONA DE CORTE | 8d | 2023-12-13 | 2023-12-22 | 1.06.04.02 |  |  | 59.22d | 0d |  | Camión Cisterna 4x2 400 HP Agua (5000 gal) [39.2 h]; CAPATAZ [19.6 h]; Motoniveladora 185 HP [39.2 h]; OFICIAL [39.2 h]; PEON [39.2 h]; Rodillo Vib. Liso Autopropulsado 135 HP 12 TM [39.2 h] |
| 1.06.04.09 |  | PREPARACIÓN DE FUNDACIÓN DE CUERPO DE DIQUE | 1d | 2023-12-22 | 2023-12-23 | 1.06.04.03 |  |  | 59.22d | 0d |  | CAPATAZ [1.02 h]; Excavadora Sobre Oruga 260 HP [2.55 h]; Motoniveladora 185 HP [10.22 h]; OPERARIO [10.22 h]; PEON [20.43 h]; Rodillo Vib. Liso Autopropulsado 135 HP 12 TM [10.22 h] |
| 1.06.04.04 |  | CONFORMACIÓN DE CUERPO DE DIQUE CON MATERIAL PROPIO | 1.67d | 2023-12-23 | 2023-12-27 | 1.06.04.09 |  |  | 59.22d | 0d |  | Camión Cisterna 4x2 400 HP Agua (5000 gal) [74.58 h]; CAPATAZ [74.58 h]; Excavadora Sobre Oruga 260 HP [74.58 h]; Motoniveladora 185 HP [74.58 h]; OFICIAL [74.58 h]; OPERARIO [74.58 h]; PEON [298.02 h]; Rodillo Vib. Liso Autopropulsado 135 HP 12 TM [74.58 h] |
| 1.06.04.06 |  | GEOTEXTIL NO TEJIDO 400 G/M2, INC. COLOCACIÓN | 11.33d | 2023-12-27 | 2024-01-11 | 1.06.04.04 |  |  | 59.22d | 0d |  | CAPATAZ [10.55 h]; OPERARIO [105.53 h]; PEON [422.13 h] |
| 1.06.04.07 |  | COLOCACION Y ACOMODO DE ROCA EN UÑA DE DIQUE | 21.67d | 2024-01-02 | 2024-01-29 | 1.06.04.06 SS+4d |  |  | 59.22d | 0d |  | Camión Volquete (15 m3) [2976.35 h]; CAPATAZ [524.72 h]; Excavadora Sobre Oruga 260 HP [427.14 h]; OPERARIO [260.09 h]; PEON [1560.34 h] |
| 1.06.04.08 |  | COLOCACION Y ACOMODO DE ROCA EN TALUD DE DIQUE | 30.33d | 2024-01-05 | 2024-02-12 | 1.06.04.07 SS+2.67d |  |  | 59.22d | 0d |  | Camión Volquete (15 m3) [2976.35 h]; CAPATAZ [721.35 h]; CUADRADOR/VIGÍA [2643.4 h]; Excavadora Sobre Oruga 260 HP [623.77 h]; OPERARIO [456.72 h]; PEON [4568.23 h] |
| 1.06.04.05 |  | CONFORMACIÓN DE CORONA DE DIQUE CON MATERIAL PROPIO | 4.67d | 2024-02-12 | 2024-02-17 | 1.06.04.08 |  |  | 59.22d |  |  | Camión Cisterna 4x2 400 HP Agua (5000 gal) [28.01 h]; CAPATAZ [28.01 h]; Excavadora Sobre Oruga 260 HP [28.01 h]; Motoniveladora 185 HP [28.01 h]; OFICIAL [28.01 h]; OPERARIO [28.01 h]; PEON [111.94 h]; Rodillo Vib. Liso Autopropulsado 135 HP 12 TM [28.01 h] |
|  | 5 | **DIQUE DE TIERRA COMPACTADA A3-I-03** |  | 2023-12-12 | 2024-04-22 |  |  |  |  |  |  |  |
| 1.06.05.01 |  | EXCAVACIÓN EN TERRENO NATURAL CON EQUIPO | 19.67d | 2023-12-12 | 2024-01-06 | 1.06.04.01 |  |  | 6.24d | 0d |  | Camión Volquete (15 m3) [2976.35 h]; CAPATAZ [281.53 h]; CUADRADOR/VIGÍA [2643.4 h]; Excavadora Sobre Oruga 260 HP [343.59 h]; PEON [176.54 h]; Tractor S/Orugas (D6T) - 180 HP [88.27 h] |
| 1.06.05.02 |  | EXCAVACIÓN DE UÑA CON EQUIPO | 19.67d | 2023-12-12 | 2024-01-06 | 1.06.05.01 SS |  |  | 6.24d | 0d |  | CAPATAZ [35.35 h]; Excavadora Sobre Oruga 260 HP [71.01 h]; PEON [71.01 h] |
| 1.06.05.03 |  | PERFILADO Y COMPACTACIÓN EN ZONA DE CORTE | 7.33d | 2023-12-15 | 2023-12-23 | 1.06.05.01 SS+3d, 1.06.05.02 SS+3d |  |  | 6.24d | 0d |  | Camión Cisterna 4x2 400 HP Agua (5000 gal) [48.82 h]; CAPATAZ [24.41 h]; Motoniveladora 185 HP [48.82 h]; OFICIAL [48.82 h]; PEON [48.82 h]; Rodillo Vib. Liso Autopropulsado 135 HP 12 TM [48.82 h] |
| 1.06.05.09 |  | PREPARACIÓN DE FUNDACIÓN DE CUERPO DE DIQUE | 4.67d | 2023-12-26 | 2023-12-30 | 1.06.05.03 |  |  | 6.24d | 0d |  | CAPATAZ [0.57 h]; Excavadora Sobre Oruga 260 HP [1.42 h]; Motoniveladora 185 HP [5.66 h]; OPERARIO [5.66 h]; PEON [11.33 h]; Rodillo Vib. Liso Autopropulsado 135 HP 12 TM [5.66 h] |
| 1.06.05.04 |  | CONFORMACIÓN DE CUERPO DE DIQUE CON MATERIAL PROPIO | 18d | 2024-01-02 | 2024-01-23 | 1.06.05.09 |  |  | 6.24d | 0d |  | Camión Cisterna 4x2 400 HP Agua (5000 gal) [15.45 h]; CAPATAZ [15.45 h]; Excavadora Sobre Oruga 260 HP [15.45 h]; Motoniveladora 185 HP [15.45 h]; OFICIAL [15.45 h]; OPERARIO [15.45 h]; PEON [61.73 h]; Rodillo Vib. Liso Autopropulsado 135 HP 12 TM [15.45 h] |
| 1.06.05.06 |  | GEOTEXTIL NO TEJIDO 400 G/M2, INC. COLOCACIÓN | 8.67d | 2024-01-24 | 2024-02-02 | 1.06.05.04 |  |  | 6.24d | 0d |  | CAPATAZ [9.5 h]; OPERARIO [95.04 h]; PEON [380.16 h] |
| 1.06.05.07 |  | COLOCACION Y ACOMODO DE ROCA EN UÑA DE DIQUE | 31d | 2024-02-03 | 2024-03-12 | 1.06.05.06 |  |  | 6.24d | 0d |  | Camión Volquete (15 m3) [2976.35 h]; CAPATAZ [619.08 h]; CUADRADOR/VIGÍA [2643.4 h]; Excavadora Sobre Oruga 260 HP [521.5 h]; OPERARIO [354.45 h]; PEON [2126.4 h] |
| 1.06.05.08 |  | COLOCACION Y ACOMODO DE ROCA EN TALUD DE DIQUE | 44d | 2024-02-08 | 2024-04-04 | 1.06.05.07 SS+4d |  |  | 6.24d | 0d |  | Camión Volquete (15 m3) [2976.35 h]; CAPATAZ [776.13 h]; CUADRADOR/VIGÍA [2643.4 h]; Excavadora Sobre Oruga 260 HP [678.55 h]; OPERARIO [511.5 h]; PEON [5116.14 h] |
| 1.06.05.05 |  | CONFORMACIÓN DE CORONA DE DIQUE CON MATERIAL PROPIO | 14.22d | 2024-04-05 | 2024-04-22 | 1.06.05.08 |  |  | 8.67d |  |  | Camión Cisterna 4x2 400 HP Agua (5000 gal) [33.2 h]; CAPATAZ [33.2 h]; Excavadora Sobre Oruga 260 HP [33.2 h]; Motoniveladora 185 HP [33.2 h]; OFICIAL [33.2 h]; OPERARIO [33.2 h]; PEON [132.69 h]; Rodillo Vib. Liso Autopropulsado 135 HP 12 TM [33.2 h] |
|  | 6 | **RAMPAS** |  | 2024-01-08 | 2024-01-15 |  |  |  |  |  |  |  |
| 1.06.01 |  | EXCAVACIÓN EN TERRENO NATURAL CON EQUIPO | 3d | 2024-01-08 | 2024-01-10 | 1.06.05.01 |  |  | 86.22d | 0d |  | CAPATAZ [0.38 h]; Excavadora Sobre Oruga 260 HP [4.02 h]; PEON [4.02 h]; Tractor S/Orugas (D6T) - 180 HP [2.01 h] |
| 1.06.02 |  | CONFORMACIÓN DE CUERPO DE RAMPA CON MATERIAL PROPIO | 2.25d | 2024-01-11 | 2024-01-12 | 1.06.01 | 2024-01-11 | 2024-01-13 | 97d | 0d | DÍAS CALENDARIOS | Camión Cisterna 4x2 400 HP Agua (5000 gal) [6.32 h]; CAPATAZ [6.32 h]; Excavadora Sobre Oruga 260 HP [6.32 h]; Motoniveladora 185 HP [6.32 h]; OFICIAL [6.32 h]; OPERARIO [6.32 h]; PEON [25.27 h]; Rodillo Vib. Liso Autopropulsado 135 HP 12 TM [6.32 h] |
| 1.06.03 |  | CONFORMACIÓN DE CORONACIÓN DE RAMPA | 1.67d | 2024-01-13 | 2024-01-15 | 1.06.02 |  |  | 86.22d |  |  | Camión Cisterna 4x2 400 HP Agua (5000 gal) [4.32 h]; CAPATAZ [4.32 h]; Excavadora Sobre Oruga 260 HP [4.32 h]; Motoniveladora 185 HP [4.32 h]; OFICIAL [4.32 h]; OPERARIO [4.32 h]; PEON [17.26 h]; Rodillo Vib. Liso Autopropulsado 135 HP 12 TM [4.32 h] |

| ID | WBS | Activity | Duration | Start | Finish | Predecessors | Total float | Free float | Resources |
| --- | --- | --- | --- | --- | --- | --- | --- | --- | --- |
|  | 2 | **OBRAS DE ARTE** |  | 2023-11-22 | 2024-03-23 |  |  |  |  |
|  | 1 | **CAPTACIÓN A3-CP-23-95** |  | 2023-11-22 | 2024-02-21 |  |  |  |  |
|  | 1 | **MOVIMIENTO DE TIERRAS** |  | 2023-11-22 | 2024-01-03 |  |  |  |  |
| 2.01.01.01 |  | EXCAVACIÓN ESTRUCTURAL PARA OBRAS DE ARTE | 6.33d | 2023-11-22 | 2023-11-29 | 1.06.04.01 SS+8d | 10.33d | 0d | CAPATAZ [5.2 h]; CUADRADOR/VIGÍA [51.99 h]; PEON [207.98 h]; Retroexcavador 58 HP [51.99 h] |
| 2.01.01.02 |  | RELLENO ESTRUCTURAL PARA OBRAS DE ARTE, CON MATERIAL PROPIO | 7.33d | 2023-12-23 | 2024-01-03 | 2.01.02.03, 2.01.02.04 FF+6d | 95.56d |  | CAPATAZ [4.86 h]; CUADRADOR/VIGÍA [48.57 h]; PEON [194.28 h]; Retroexcavador 58 HP [12.15 h]; Rodillo Vib. Liso Autopropulsado 135 HP 12 TM [48.57 h] |
|  | 2 | **OBRAS DE CONCRETO** |  | 2023-11-30 | 2023-12-26 |  |  |  |  |
| 2.01.02.01 |  | CONCRETO f'c=100 kg/cm2 | 1d | 2023-11-30 | 2023-11-30 | 2.01.01.01 | 95.56d | 0d | CAPATAZ [0.25 h]; OFICIAL [1.23 h]; OPERARIO [2.45 h]; PEON [12.27 h] |
| 2.01.02.05 |  | ACERO DE REFUERZO fy=4200 kg/cm2 | 7.67d | 2023-12-01 | 2023-12-12 | 2.01.02.01 | 95.56d | 0d | CAPATAZ [22.75 h]; OPERARIO [229.58 h]; PEON [229.58 h] |
| 2.01.02.04 |  | ENCOFRADO Y DESENCOFRADO RECTO | 14.33d | 2023-12-05 | 2023-12-26 | 2.01.02.05 SS+2d, 2.01.02.03 FF+1d | 95.89d | 0.33d | CAPATAZ [31.4 h]; OPERARIO [62.8 h]; PEON [62.8 h] |
| 2.01.02.02 |  | CONCRETO f'c=280 kg/cm2 | 7.67d | 2023-12-13 | 2023-12-21 | 2.01.02.05 | 95.56d | 0d | OFICIAL [122.05 h]; OPERARIO [61.02 h]; PEON [610.24 h] |
| 2.01.02.03 |  | CONCRETO CICLÓPEO f'c=280 kg/cm2 + 30% P.G. | 1d | 2023-12-22 | 2023-12-22 | 2.01.02.02 | 95.56d | 0d | CAPATAZ [0.45 h]; OPERARIO [2.24 h]; PEON [4.48 h] |
|  | 3 | **ESTRUCTURAS METALICAS** |  | 2023-12-22 | 2023-12-27 |  |  |  |  |
| 2.01.03.01 |  | COMPUERTA METALICA PLANA DESLIZANTE DE 1.0x1.0m | 1d | 2023-12-22 | 2023-12-22 | 2.01.02.02 | 100.22d | 0d | OFICIAL [4 h]; OPERARIO [4 h]; PEON [12 h] |
| 2.01.03.02 |  | REJILLA DE 1.00x1.00m CON VARILLA DE 1/2" CADA 6,25cm | 1d | 2023-12-22 | 2023-12-22 | 2.01.03.01 SS | 100.22d | 0d | OPERARIO [1.6 h]; PEON [3.2 h] |
| 2.01.03.03 |  | BARANDA DE FIERRO GALVANIZADO 1 1/2" | 0.67d | 2023-12-23 | 2023-12-23 | 2.01.03.02 SS+1d | 100.22d | 0d | CAPATAZ [0.12 h]; OFICIAL [2.4 h]; OPERARIO [2.4 h]; PEON [1.2 h] |
| 2.01.03.04 |  | ESCALERA TIPO GATO | 1d | 2023-12-26 | 2023-12-26 | 2.01.03.03 SS+0.67d | 100.22d | 0d | CAPATAZ [0.2 h]; OPERARIO [2 h]; PEON [4 h] |
| 2.01.03.05 |  | TAPA METALICA CIRCULAR DN600 MM | 1d | 2023-12-27 | 2023-12-27 | 2.01.03.04 | 100.22d |  | OPERARIO [5.33 h]; PEON [5.33 h] |
|  | 4 | **TUBERIAS** |  | 2023-11-30 | 2023-12-30 |  |  |  |  |
| 2.01.04.01 |  | EXCAVACIÓN ESTRUCTURAL PARA OBRAS DE ARTE (Buzones) | 2.67d | 2023-11-30 | 2023-12-02 | 2.01.01.01 | 55.89d | 0d | CAPATAZ [1.85 h]; CUADRADOR/VIGÍA [18.46 h]; PEON [73.86 h]; Retroexcavador 58 HP [18.46 h] |
| 2.01.04.02 |  | EXCAVACIÓN DE ZANJA | 10.67d | 2023-11-30 | 2023-12-14 | 2.01.04.01 SS | 55.89d | 0d | CAPATAZ [8.19 h]; CUADRADOR/VIGÍA [81.86 h]; PEON [327.45 h]; Retroexcavador 58 HP [81.86 h] |
| 2.01.04.06 |  | CONCRETO f'c=100 kg/cm2 (Buzones) | 1d | 2023-12-04 | 2023-12-04 | 2.01.04.01 | 55.89d | 0d | CAPATAZ [0.25 h]; OFICIAL [1.23 h]; OPERARIO [2.45 h]; PEON [12.27 h] |
| 2.01.04.10 |  | ACERO DE REFUERZO fy=4200 kg/cm2 (Buzones) | 3d | 2023-12-05 | 2023-12-07 | 2.01.04.06 | 55.89d | 0d | CAPATAZ [1.88 h]; OPERARIO [18.94 h]; PEON [18.94 h] |
| 2.01.04.08 |  | ENCOFRADO Y DESENCOFRADO RECTO | 2d | 2023-12-11 | 2023-12-12 | 2.01.04.10 | 55.89d | 0d | CAPATAZ [31.4 h]; OPERARIO [62.8 h]; PEON [62.8 h] |
| 2.01.04.09 |  | ENCOFRADO Y DESENCOFRADO CURVO | 3d | 2023-12-11 | 2023-12-13 | 2.01.04.08 SS | 55.89d | 0d | CAPATAZ [8.14 h]; OPERARIO [16.29 h]; PEON [16.29 h] |
| 2.01.04.07 |  | CONCRETO f'c=280 kg/cm2 (Buzones) | 1d | 2023-12-14 | 2023-12-14 | 2.01.04.09 | 55.89d | 0d | OFICIAL [11.39 h]; OPERARIO [5.7 h]; PEON [59.96 h] |
| 2.01.04.03 |  | RELLENO ESTRUCTURAL PARA OBRAS DE ARTE CON MATERIAL PROPIO (Buzones) | 2d | 2023-12-15 | 2023-12-18 | 2.01.04.07 | 55.89d | 0d | CAPATAZ [1.17 h]; CUADRADOR/VIGÍA [11.65 h]; PEON [46.6 h]; Retroexcavador 58 HP [2.91 h]; Rodillo Vib. Liso Autopropulsado 135 HP 12 TM [11.65 h] |
| 2.01.04.04 |  | CAMA DE ARENA | 1d | 2023-12-15 | 2023-12-15 | 2.01.04.02 | 89.89d | 0d | CAPATAZ [2.78 h]; PEON [22.21 h] |
| 2.01.04.11 |  | SUMINISTRO E INSTALACIÓN DE TUBERÍA GRP DN600 mm SN2500 | 1.67d | 2023-12-16 | 2023-12-18 | 2.01.04.04 | 89.89d | 0d | CAPATAZ [1.26 h]; CUADRADOR/VIGÍA [12.62 h]; OFICIAL [12.62 h]; PEON [25.24 h]; Retroexcavador 58 HP [12.62 h] |
| 2.01.04.05 |  | RELLENO COMÚN PARA ZANJAS | 9.33d | 2023-12-19 | 2023-12-30 | 2.01.04.11 | 89.89d | 34d | Camión Cisterna 4x2 400 HP Agua (5000 gal) [78.59 h]; CAPATAZ [7.86 h]; CUADRADOR/VIGÍA [78.59 h]; PEON [314.36 h]; Rodillo Vib. Liso Autopropulsado 135 HP 12 TM [78.59 h] |

| ID | WBS | Activity | Duration | Start | Finish | Predecessors | Total float | Free float | Resources |
| --- | --- | --- | --- | --- | --- | --- | --- | --- | --- |
|  | 5 | **CANAL** |  | 2023-12-15 | 2024-02-10 |  |  |  |  |
| 2.01.05.01 |  | EXCAVACIÓN ESTRUCTURAL PARA OBRAS DE ARTE | 6.67d | 2023-12-15 | 2023-12-22 | 2.01.04.02, 2.01.04.03 SS | 55.89d | 0d | CAPATAZ [5.2 h]; CUADRADOR/VIGÍA [51.99 h]; PEON [207.98 h] |
| 2.01.05.03 |  | COLOCACIÓN DE CONCRETO f'c=100 kg/cm2 | 2.67d | 2023-12-23 | 2023-12-27 | 2.01.05.01 | 55.89d | 0d | CAPATAZ [3.98 h]; OFICIAL [19.9 h]; OPERARIO [39.8 h]; PEON [198.99 h] |
| 2.01.05.06 |  | ACERO DE REFUERZO fy=4200 kg/cm2 | 9.33d | 2023-12-28 | 2024-01-09 | 2.01.05.03 | 55.89d | 0d | CAPATAZ [22.75 h]; OPERARIO [229.58 h]; PEON [229.58 h] |
| 2.01.05.05 |  | ENCOFRADO Y DESENCOFRADO RECTO | 27.33d | 2024-01-02 | 2024-02-03 | 2.01.05.06 SS+2.67d | 55.89d | 0d | CAPATAZ [21.4 h]; OPERARIO [62.8 h]; PEON [62.8 h] |
| 2.01.05.04 |  | COLOCACIÓN DE CONCRETO f'c=280 kg/cm2 | 18.67d | 2024-01-05 | 2024-01-27 | 2.01.05.05 SS+3d | 55.89d | 0d | OFICIAL [174.63 h]; OPERARIO [87.31 h]; PEON [873.11 h] |
| 2.01.05.07 |  | JUNTA WATER STOP SIN BULBO 150 mm | 3d | 2024-01-29 | 2024-01-31 | 2.01.05.04 | 55.89d | 0d | OPERARIO [16.08 h]; PEON [16.08 h] |
| 2.01.05.02 |  | RELLENO ESTRUCTURAL PARA CANALES, CON MATERIAL PROPIO | 8.33d | 2024-02-01 | 2024-02-10 | 2.01.05.07, 2.01.04.05 SS | 55.89d | 0d | CAPATAZ [13.06 h]; CUADRADOR/VIGÍA [130.48 h]; PEON [521.87 h] |
|  | 6 | **OBRAS DE DESCARGA** |  | 2024-02-12 | 2024-02-21 |  |  |  |  |
| 2.01.06.01 |  | EXCAVACIÓN ESTRUCTURAL PARA OBRAS DE ARTE | 1d | 2024-02-12 | 2024-02-12 | 2.01.05.02 | 55.89d | 0d | CAPATAZ [5.2 h]; CUADRADOR/VIGÍA [51.99 h]; PEON [207.98 h] |
| 2.01.06.03 |  | CONCRETO f'c=100 kg/cm2 | 1d | 2024-02-13 | 2024-02-13 | 2.01.06.01 | 55.89d | 0d | CAPATAZ [0.25 h]; OFICIAL [1.23 h]; OPERARIO [2.45 h]; PEON [12.27 h] |
| 2.01.06.06 |  | ACERO DE REFUERZO fy=4200 kg/cm2 | 1d | 2024-02-14 | 2024-02-14 | 2.01.06.03 | 55.89d | 0d | CAPATAZ [22.75 h]; OPERARIO [229.58 h]; PEON [229.58 h] |
| 2.01.06.04 |  | CONCRETO f'c=280 kg/cm2 | 1d | 2024-02-15 | 2024-02-15 | 2.01.06.05 SS | 55.89d | 0d | OFICIAL [122.05 h]; OPERARIO [61.02 h]; PEON [610.24 h] |
| 2.01.06.05 |  | ENCOFRADO Y DESENCOFRADO RECTO | 2.67d | 2024-02-15 | 2024-02-17 | 2.01.06.06 | 55.89d | 0d | CAPATAZ [31.4 h]; OPERARIO [62.8 h]; PEON [62.8 h] |
| 2.01.06.07 |  | JUNTA WATER STOP SIN BULBO 150 mm | 2.67d | 2024-02-16 | 2024-02-19 | 2.01.06.04 | 55.89d | 0d | OPERARIO [16.08 h]; PEON [16.08 h] |
| 2.01.06.02 |  | RELLENO ESTRUCTURAL PARA OBRAS DE ARTE CON MATERIAL PROPIO | 1d | 2024-02-20 | 2024-02-20 | 2.01.06.07 | 55.89d | 0d | CAPATAZ [0.47 h]; CUADRADOR/VIGÍA [4.66 h]; PEON [18.62 h] |
| 2.01.06.08 |  | COMPUERTA METALICA PLANA DESLIZANTE | 1d | 2024-02-21 | 2024-02-21 | 2.01.06.02 | 55.89d |  | OFICIAL [8 h]; OPERARIO [8 h]; PEON [24 h] |
|  | 2 | **CAPTACIÓN A3-CP-21-05** |  | 2023-11-22 | 2024-01-26 |  |  |  |  |
|  | 1 | **MOVIMIENTO DE TIERRAS** |  | 2023-11-22 | 2024-01-26 |  |  |  |  |
| 2.02.01.01 |  | EXCAVACIÓN ESTRUCTURAL PARA OBRAS DE ARTE | 4.23d | 2023-11-22 | 2023-11-27 | 2.01.01.01 SS+0.1d | 10.33d | 0d | CAPATAZ [5.2 h]; CUADRADOR/VIGÍA [51.99 h]; PEON [207.98 h]; Retroexcavador 58 HP [51.99 h] |
| 2.02.01.02 |  | RELLENO ESTRUCTURAL PARA OBRAS DE ARTE, CON MATERIAL PROPIO | 7.67d | 2024-01-18 | 2024-01-26 | 2.02.02.03 | 64.56d | 58.32d | CAPATAZ [4.86 h]; CUADRADOR/VIGÍA [48.57 h]; PEON [194.28 h]; Retroexcavador 58 HP [12.15 h]; Rodillo Vib. Liso Autopropulsado 135 HP 12 TM [48.57 h] |
|  | 2 | **OBRAS DE CONCRETO** |  | 2023-11-28 | 2024-01-22 |  |  |  |  |
| 2.02.02.01 |  | CONCRETO f'c=100 kg/cm2 | 1d | 2023-11-28 | 2023-11-28 | 2.02.01.01 | 64.56d | 0d | CAPATAZ [0.25 h]; OFICIAL [1.23 h]; OPERARIO [2.45 h]; PEON [12.27 h] |
| 2.02.02.05 |  | ACERO DE REFUERZO fy=4200 kg/cm2 | 28.33d | 2023-11-29 | 2024-01-06 | 2.02.02.01 | 64.56d | 0d | CAPATAZ [22.75 h]; OPERARIO [229.58 h]; PEON [229.58 h] |
| 2.02.02.04 |  | ENCOFRADO Y DESENCOFRADO RECTO | 37.67d | 2023-12-02 | 2024-01-22 | 2.02.02.05 SS+3d | 67.56d | 0d | CAPATAZ [31.4 h]; OPERARIO [62.8 h]; PEON [62.8 h] |
| 2.02.02.02 |  | CONCRETO f'c=280 kg/cm2 | 7.67d | 2024-01-08 | 2024-01-16 | 2.02.02.05 | 64.56d | 0d | OFICIAL [122.05 h]; OPERARIO [61.02 h]; PEON [610.24 h] |
| 2.02.02.03 |  | CONCRETO CICLÓPEO f'c=280 kg/cm2 + 30% P.G. | 1d | 2024-01-17 | 2024-01-17 | 2.02.02.02 | 64.56d | 0d | CAPATAZ [0.45 h]; OPERARIO [2.24 h]; PEON [4.48 h] |

| ID | WBS | Activity | Duration | Start | Finish | Predecessors | Total float | Free float | Resources |
| --- | --- | --- | --- | --- | --- | --- | --- | --- | --- |
|  | 3 | **ESTRUCTURAS METALICAS** |  | 2024-01-17 | 2024-01-23 |  |  |  |  |
| 2.02.03.01 |  | COMPUERTA METALICA PLANA DESLIZANTE DE 1.0x1.0m | 1d | 2024-01-17 | 2024-01-17 | 2.02.02.02 | 67.56d | 0d | OFICIAL [4 h]; OPERARIO [4 h]; PEON [12 h] |
| 2.02.03.02 |  | REJILLA DE 1.00x1.00m CON VARILLA DE 1/2 CADA 6,25cm | 1d | 2024-01-17 | 2024-01-17 | 2.02.03.01 SS | 67.56d | 0d | OPERARIO [1.6 h]; PEON [3.2 h] |
| 2.02.03.03 |  | BARANDA DE FIERRO GALVANIZADO 1 1/2" | 1d | 2024-01-18 | 2024-01-18 | 2.02.03.02 SS+1d | 67.56d | 0d | CAPATAZ [0.12 h]; OFICIAL [2.4 h]; OPERARIO [2.4 h]; PEON [1.2 h] |
| 2.02.03.04 |  | ESCALERA TIPO GATO | 0.67d | 2024-01-22 | 2024-01-22 | 2.02.03.03 FS+2d | 67.56d | 0d | CAPATAZ [0.2 h]; OPERARIO [2 h]; PEON [4 h] |
| 2.02.03.05 |  | TAPA METALICA CIRCULAR DN600 MM | 1d | 2024-01-23 | 2024-01-23 | 2.02.03.04, 2.02.02.04 | 67.56d | 61.32d | OPERARIO [5.33 h]; PEON [5.33 h] |
|  | 4 | **TUBERIA** |  | 2023-11-28 | 2023-12-06 |  |  |  |  |
| 2.02.04.01 |  | EXCAVACIÓN ESTRUCTURAL PARA OBRAS DE ARTE (Buzones) | 1d | 2023-11-28 | 2023-11-28 | 2.02.01.01 | 10.33d | 0d | CAPATAZ [1.85 h]; CUADRADOR/VIGÍA [18.46 h]; PEON [73.86 h]; Retroexcavador 58 HP [18.46 h] |
| 2.02.04.02 |  | EXCAVACIÓN DE ZANJA | 1d | 2023-11-28 | 2023-11-28 | 2.02.04.01 SS | 71.22d | 0d | CAPATAZ [8.19 h]; CUADRADOR/VIGÍA [81.86 h]; PEON [327.45 h]; Retroexcavador 58 HP [81.86 h] |
| 2.02.04.04 |  | CAMA DE ARENA | 1d | 2023-11-29 | 2023-11-29 | 2.02.04.02 | 71.22d | 0d | CAPATAZ [2.78 h]; PEON [22.21 h] |
| 2.02.04.07 |  | CONCRETO f'c=100 kg/cm2 (Buzones) | 1d | 2023-11-29 | 2023-11-29 | 2.02.04.01 | 32.22d | 0d | CAPATAZ [0.25 h]; OFICIAL [1.23 h]; OPERARIO [2.45 h]; PEON [12.27 h] |
| 2.02.04.11 |  | ACERO DE REFUERZO fy=4200 kg/cm2 | 1d | 2023-11-30 | 2023-11-30 | 2.02.04.07 | 32.22d | 0d | CAPATAZ [1.88 h]; OPERARIO [18.94 h]; PEON [18.94 h] |
| 2.02.04.12 |  | SUMINISTRO E INSTALACIÓN DE TUBERÍA GRP DN600 mm SN2500 | 1d | 2023-11-30 | 2023-11-30 | 2.02.04.04 | 71.22d | 0d | CAPATAZ [0.09 h]; Excavadora Sobre Oruga 260 HP [0.91 h]; OFICIAL [0.91 h]; PEON [1.81 h] |
| 2.02.04.05 |  | RELLENO SELECCIONADO PARA ZANJAS CON MATERIAL PROPIO | 2.67d | 2023-12-01 | 2023-12-04 | 2.02.04.12 | 71.22d | 0d | CAPATAZ [0.96 h]; CUADRADOR/VIGÍA [9.63 h]; PEON [38.53 h]; Retroexcavador 58 HP [2.41 h]; Rodillo Vib. Liso Autopropulsado 135 HP 12 TM [9.63 h] |
| 2.02.04.09 |  | ENCOFRADO Y DESENCOFRADO RECTO | 1d | 2023-12-01 | 2023-12-01 | 2.02.04.11 | 32.22d | 0d | CAPATAZ [31.4 h]; OPERARIO [62.8 h]; PEON [62.8 h] |
| 2.02.04.10 |  | ENCOFRADO Y DESENCOFRADO CURVO | 2.67d | 2023-12-02 | 2023-12-05 | 2.02.04.09 | 32.22d | 0d | CAPATAZ [8.14 h]; OPERARIO [16.29 h]; PEON [16.29 h] |
| 2.02.04.08 |  | CONCRETO f'c=280 kg/cm2 (Buzones) | 1d | 2023-12-04 | 2023-12-04 | 2.02.04.10 SS+0.67d | 71.22d | 0d | OFICIAL [11.39 h]; OPERARIO [5.7 h]; PEON [56.96 h] |
| 2.02.04.06 |  | RELLENO COMÚN PARA ZANJAS | 1d | 2023-12-05 | 2023-12-05 | 2.02.04.05, 2.02.04.08 | 71.22d | 0d | Camión Cisterna 4x2 400 HP Agua (5000 gal) [78.59 h]; CAPATAZ [7.86 h]; CUADRADOR/VIGÍA [78.59 h]; PEON [314.36 h]; Rodillo Vib. Liso Autopropulsado 135 HP 12 TM [78.59 h] |
| 2.02.04.03 |  | RELLENO ESTRUCTURAL PARA OBRAS DE ARTE CON MATERIAL PROPIO | 1d | 2023-12-06 | 2023-12-06 | 2.02.04.10 | 32.22d | 0d | CAPATAZ [1.17 h]; CUADRADOR/VIGÍA [11.65 h]; PEON [46.6 h]; Retroexcavador 58 HP [2.91 h]; Rodillo Vib. Liso Autopropulsado 135 HP 12 TM [11.65 h] |
|  | 5 | **CANALES** |  | 2023-11-28 | 2024-01-18 |  |  |  |  |
| 2.02.05.01 |  | EXCAVACIÓN ESTRUCTURAL PARA OBRAS DE ARTE | 5.67d | 2023-11-28 | 2023-12-04 | 2.02.04.01 SS | 10.33d | 0d | CAPATAZ [5.2 h]; CUADRADOR/VIGÍA [51.99 h]; PEON [207.98 h] |
| 2.02.05.03 |  | COLOCACIÓN DE CONCRETO f'c=100 kg/cm2 | 1d | 2023-12-05 | 2023-12-05 | 2.02.05.01 | 71.22d | 0d | CAPATAZ [3.98 h]; OFICIAL [19.9 h]; OPERARIO [39.8 h]; PEON [198.99 h] |
| 2.02.05.06 |  | ACERO DE REFUERZO fy=4200 kg/cm2 | 10d | 2023-12-06 | 2023-12-20 | 2.02.05.03, 2.02.04.06 | 71.22d | 0d | CAPATAZ [22.75 h]; OPERARIO [229.58 h]; PEON [229.58 h] |
| 2.02.05.05 |  | ENCOFRADO Y DESENCOFRADO | 22.67d | 2023-12-11 | 2024-01-09 | 2.02.05.06 SS+2d | 71.22d | 0d | CAPATAZ [31.4 h]; OPERARIO [62.8 h]; PEON [62.8 h] |
| 2.02.05.07 |  | JUNTA WATER STOP SIN BULBO 150 mm | 1d | 2023-12-14 | 2023-12-14 | 2.02.05.05 SS+3d | 87.22d | 0d | OPERARIO [16.08 h]; PEON [16.08 h] |
| 2.02.05.04 |  | COLOCACIÓN DE CONCRETO f'c=280 kg/cm2 | 2.67d | 2023-12-15 | 2023-12-18 | 2.02.05.07 | 87.22d | 16d | OFICIAL [174.63 h]; OPERARIO [87.31 h]; PEON [873.11 h] |
| 2.02.05.02 |  | RELLENO ESTRUCTURAL PARA CANALES, CON MATERIAL PROPIO | 7.67d | 2024-01-10 | 2024-01-18 | 2.02.05.05, 2.02.05.04 | 71.22d | 64.98d | CAPATAZ [13.06 h]; CUADRADOR/VIGÍA [130.48 h]; PEON [521.87 h]; Retroexcavador 58 HP [32.63 h]; Rodillo Vib. Liso Autopropulsado 135 HP 12 TM [130.48 h] |

| ID | WBS | Activity | Duration | Start | Finish | Predecessors | Total float | Free float | Resources |
| --- | --- | --- | --- | --- | --- | --- | --- | --- | --- |
|  | 3 | **RETORNO A3-OA-RE-D-21-55** |  | 2023-11-28 | 2024-01-06 |  |  |  |  |
|  | 1 | **MOVIMIENTO DE TIERRAS** |  | 2023-11-28 | 2024-01-05 |  |  |  |  |
| 2.03.01.01 |  | EXCAVACIÓN ESTRUCTURAL PARA OBRAS DE ARTE | 1d | 2023-11-28 | 2023-11-28 | 2.02.05.01 SS | 10.33d | 0d | CAPATAZ [5.2 h]; CUADRADOR/VIGÍA [51.99 h]; PEON [207.98 h]; Retroexcavador 58 HP [51.99 h] |
| 2.03.01.02 |  | RELLENO ESTRUCTURAL PARA OBRAS DE ARTE, CON MATERIAL PROPIO | 1d | 2024-01-05 | 2024-01-05 | 2.03.02.03 | 81.56d | 75.32d | CAPATAZ [4.86 h]; CUADRADOR/VIGÍA [48.57 h]; PEON [194.28 h]; Retroexcavador 58 HP [12.15 h]; Rodillo Vib. Liso Autopropulsado 135 HP 12 TM [48.57 h] |
|  | 2 | **OBRAS DE CONCRETO** |  | 2023-11-29 | 2024-01-06 |  |  |  |  |
| 2.03.02.01 |  | CONCRETO f'c=100 kg/cm2 | 1d | 2023-11-29 | 2023-11-29 | 2.03.01.01 | 10.33d | 0d | CAPATAZ [0.25 h]; OFICIAL [1.23 h]; OPERARIO [2.45 h]; PEON [12.27 h] |
| 2.03.02.05 |  | ACERO DE REFUERZO fy=4200 kg/cm2 | 18d | 2023-11-30 | 2023-12-23 | 2.03.02.01 | 10.33d | 0d | CAPATAZ [22.75 h]; OPERARIO [229.58 h]; PEON [229.58 h] |
| 2.03.02.04 |  | ENCOFRADO Y DESENCOFRADO | 21.67d | 2023-12-07 | 2024-01-06 | 2.03.02.05 SS+5.67d, 2.02.04.03 | 32.22d | 1d | CAPATAZ [31.4 h]; OPERARIO [62.8 h]; PEON [62.8 h] |
| 2.03.02.06 |  | JUNTA WATER STOP SIN BULBO 150 mm | 3d | 2023-12-26 | 2023-12-28 | 2.03.02.05 | 81.56d | 0d | OPERARIO [16.08 h]; PEON [16.08 h] |
| 2.03.02.02 |  | CONCRETO f'c=280 kg/cm2 | 2.67d | 2023-12-29 | 2024-01-02 | 2.03.02.06 | 81.56d | 0d | OFICIAL [122.05 h]; OPERARIO [61.02 h]; PEON [610.24 h] |
| 2.03.02.03 |  | CONCRETO CICLÓPEO f'c=280 kg/cm2 + 30% P.G. | 2d | 2024-01-03 | 2024-01-04 | 2.03.02.02 | 81.56d | 0d | CAPATAZ [0.45 h]; OPERARIO [2.24 h]; PEON [4.48 h] |
|  | 3 | **ESTRUCTURAS METALICAS** |  | 2024-01-03 | 2024-01-04 |  |  |  |  |
| 2.03.03.01 |  | COMPUERTA METALICA PLANA DESLIZANTE DE 1.0x1.6 m | 2d | 2024-01-03 | 2024-01-04 | 2.03.02.02 | 83.56d | 0d | OFICIAL [4 h]; OPERARIO [4 h]; PEON [12 h] |
| 2.03.03.02 |  | BARANDA DE FIERRO GALVANIZADO 1 1/2" | 1d | 2024-01-03 | 2024-01-03 | 2.03.03.01 SS | 83.56d | 77.32d | CAPATAZ [0.12 h]; OFICIAL [2.4 h]; OPERARIO [2.4 h]; PEON [1.2 h] |
|  | 4 | **REPOSICIÓN DE CANALES** |  | 2023-12-23 | 2024-03-23 |  |  |  |  |
|  | 1 | **REPOSICIÓN DE CANAL 1** |  | 2023-12-23 | 2024-03-23 |  |  |  |  |
|  | 1 | **MOVIMIENTO DE TIERRAS** |  | 2023-12-23 | 2024-03-02 |  |  |  |  |
| 2.04.01.01.01 |  | DEMOLICIÓN DE ESTRUCTURAS EXISTENTES | 8.33d | 2023-12-23 | 2024-01-04 | 2.03.02.05 SS+17.33d | 10.33d | 0d | CAPATAZ [6.98 h]; CUADRADOR/VIGÍA [69.68 h]; Excavadora Sobre Oruga 260 HP [69.68 h]; OPERARIO [139.32 h]; PEON [139.32 h] |
| 2.04.01.01.02 |  | EXCAVACIÓN EN TERRENO NATURAL CON EQUIPO | 2.67d | 2024-01-05 | 2024-01-08 | 2.04.01.01.01 | 31.22d | 0d | CAPATAZ [2.42 h]; CUADRADOR/VIGÍA [23.12 h]; Excavadora Sobre Oruga 260 HP [23.12 h]; PEON [45.89 h]; Tractor S/Orugas (D6T) - 180 HP [23.12 h] |
| 2.04.01.01.03 |  | RELLENO ESTRUCTURAL PARA OBRAS DE ARTE CON MATERIAL PROPIO | 14d | 2024-02-15 | 2024-03-02 | 2.04.01.02.04 | 33.56d | 2d | CAPATAZ [0.47 h]; CUADRADOR/VIGÍA [4.66 h]; PEON [18.62 h]; Retroexcavador 58 HP [1.16 h]; Rodillo Vib. Liso Autopropulsado 135 HP 12 TM [4.66 h] |
|  | 2 | **OBRAS DE CONCRETO** |  | 2024-01-09 | 2024-03-23 |  |  |  |  |
| 2.04.01.02.03 |  | CONCRETO f'c=100 kg/cm2 | 8.67d | 2024-01-09 | 2024-01-18 | 2.04.01.01.02, 2.03.02.04 | 31.22d | 0d | CAPATAZ [0.25 h]; OFICIAL [1.23 h]; OPERARIO [2.45 h]; PEON [12.27 h] |
| 2.04.01.02.02 |  | ACERO DE REFUERZO fy=4200 kg/cm2 | 25.33d | 2024-01-19 | 2024-02-19 | 2.04.01.02.03 | 31.22d | 0d | CAPATAZ [22.75 h]; OPERARIO [229.58 h]; PEON [229.58 h] |
| 2.04.01.02.01 |  | ENCOFRADO Y DESENCOFRADO RECTO | 49d | 2024-01-24 | 2024-03-23 | 2.04.01.02.02 SS+3.67d | 31.22d | 0d | CAPATAZ [31.4 h]; OPERARIO [62.8 h]; PEON [62.8 h] |
| 2.04.01.02.05 |  | JUNTA WATER STOP 6" | 2.67d | 2024-01-26 | 2024-01-29 | 2.04.01.02.01 SS+2d | 33.56d | 0d | OPERARIO [47.42 h]; PEON [47.42 h] |
| 2.04.01.02.04 |  | CONCRETO f'c=280 kg/cm2 | 14.33d | 2024-01-29 | 2024-02-14 | 2.04.01.02.05 SS+1.67d | 33.56d | 0d | OFICIAL [122.05 h]; OPERARIO [61.02 h]; PEON [610.24 h] |
| 2.04.01.02.06 |  | MAMPOSTERIA DE PIEDRA, e=20cm, ACABADO CARA VISTA | 1d | 2024-02-15 | 2024-02-15 | 2.04.01.02.04 | 47.56d | 16d | CAPATAZ [0.24 h]; OFICIAL [2.4 h]; OPERARIO [2.4 h]; PEON [12 h] |

| ID | WBS | Activity | Duration | Start | Finish | Predecessors | Total float | Free float | Resources |
| --- | --- | --- | --- | --- | --- | --- | --- | --- | --- |
|  | 2 | **REPOSICIÓN DE CANAL 3** |  | 2024-01-05 | 2024-03-07 |  |  |  |  |
|  | 1 | **MOVIMIENTO DE TIERRAS** |  | 2024-01-05 | 2024-03-06 |  |  |  |  |
| 2.04.02.01.01 |  | DEMOLICIÓN DE ESTRUCTURAS EXISTENTES | 5.67d | 2024-01-05 | 2024-01-11 | 2.04.01.01.01 | 10.33d | 0d | CAPATAZ [6.98 h]; CUADRADOR/VIGÍA [69.68 h]; Excavadora Sobre Oruga 260 HP [69.68 h]; OPERARIO [139.32 h]; PEON [139.32 h] |
| 2.04.02.01.02 |  | EXCAVACIÓN EN TERRENO NATURAL CON EQUIPO | 1d | 2024-01-12 | 2024-01-12 | 2.04.02.01.01 | 31.56d | 0d | CAPATAZ [2.42 h]; CUADRADOR/VIGÍA [23.12 h]; Excavadora Sobre Oruga 260 HP [23.12 h]; PEON [45.89 h]; Tractor S/Orugas (D6T) - 180 HP [23.12 h] |
| 2.04.02.01.03 |  | RELLENO ESTRUCTURAL PARA OBRAS DE ARTE CON MATERIAL PROPIO | 1d | 2024-03-06 | 2024-03-06 | 2.04.02.02.01, 2.04.01.01.03 | 31.56d | 0d | CAPATAZ [0.47 h]; CUADRADOR/VIGÍA [4.66 h]; PEON [18.62 h]; Retroexcavador 58 HP [1.16 h]; Rodillo Vib. Liso Autopropulsado 135 HP 12 TM [4.66 h] |
|  | 2 | **OBRAS DE CONCRETO** |  | 2024-01-13 | 2024-03-07 |  |  |  |  |
| 2.04.02.02.04 |  | CONCRETO f'c=100 kg/cm2 | 2.67d | 2024-01-13 | 2024-01-16 | 2.04.02.01.02 | 31.56d | 0d | CAPATAZ [0.25 h]; OFICIAL [1.23 h]; OPERARIO [2.45 h]; PEON [12.27 h] |
| 2.04.02.02.03 |  | MALLA ELECTROSOLDADA DE DN6mm EN CUADRICULA 15x15 cm | 29.33d | 2024-01-17 | 2024-02-21 | 2.04.02.02.04 | 31.56d | 0d | CAPATAZ [74.09 h]; OPERARIO [740.91 h]; PEON [1481.82 h] |
| 2.04.02.02.02 |  | ENCOFRADO Y DESENCOFRADO RECTO | 25.33d | 2024-02-01 | 2024-03-02 | 2.04.02.02.03 SS+12.33d | 31.56d | 0d | CAPATAZ [31.4 h]; OPERARIO [62.8 h]; PEON [62.8 h] |
| 2.04.02.02.05 |  | CONCRETO f'c=280 kg/cm2 | 3.67d | 2024-02-22 | 2024-02-26 | 2.04.02.02.03 | 31.56d | 0d | OFICIAL [122.05 h]; OPERARIO [61.02 h]; PEON [610.24 h] |
| 2.04.02.02.06 |  | SELLO DE JUNTA CONSTRUCCIÓN CON MATERIAL ELASTOMÉRICO | 7.67d | 2024-02-27 | 2024-03-06 | 2.04.02.02.05 | 31.56d | 0d | CAPATAZ [12.36 h]; OFICIAL [123.55 h]; PEON [123.55 h] |
| 2.04.02.02.01 |  | ENCOFRADO Y DESENCOFRADO PARA REVESTIMIENTO DE CANALES (CERCHAS) | 2d | 2024-03-04 | 2024-03-05 | 2.04.02.02.02 | 31.56d | 0d | CAPATAZ [7.21 h]; OPERARIO [14.41 h]; PEON [14.41 h] |
| 2.04.02.02.07 |  | MAMPOSTERIA DE PIEDRA, e=20cm, ACABADO CARA VISTA | 1d | 2024-03-07 | 2024-03-07 | 2.04.02.02.06, 2.04.01.02.06, 2.04.02.01.03 | 31.56d | 25.32d | CAPATAZ [0.24 h]; OFICIAL [2.4 h]; OPERARIO [2.4 h]; PEON [12 h] |
|  | 3 | **REPOSICIÓN SIFON INOPERATIVO** |  | 2024-01-12 | 2024-02-14 |  |  |  |  |
| 2.05.01 |  | DEMOLICIÓN DE ESTRUCTURAS EXISTENTES | 1d | 2024-01-12 | 2024-01-12 | 2.04.02.01.01 | 10.33d | 0d | CAPATAZ [6.98 h]; CUADRADOR/VIGÍA [69.68 h]; Excavadora Sobre Oruga 260 HP [69.68 h]; OPERARIO [139.32 h]; PEON [139.32 h] |
| 2.05.02 |  | EXCAVACIÓN ESTRUCTURAL PARA OBRAS DE ARTE | 11.33d | 2024-01-13 | 2024-01-26 | 2.05.01 | 10.33d | 0d | CAPATAZ [5.2 h]; CUADRADOR/VIGÍA [51.99 h]; PEON [207.98 h]; Retroexcavador 58 HP [51.99 h] |
| 2.05.03 |  | COLOCACIÓN CAMA DE ARENA | 0.67d | 2024-01-27 | 2024-01-27 | 2.05.02 | 10.33d | 0d | CAPATAZ [1.47 h]; PEON [11.79 h] |
| 2.05.06 |  | TUBERÍAS DE 14" HDPE SDR21 DN 355mm | 8.67d | 2024-01-29 | 2024-02-07 | 2.05.03 | 10.33d | 0d | CAPATAZ [7 h]; OPERARIO [70.06 h]; PEON [210.21 h]; Retroexcavador 58 HP [70.06 h] |
| 2.05.05 |  | RELLENO COMÚN | 4.44d | 2024-02-08 | 2024-02-13 | 2.05.06 | 11.56d | 1.22d | Camión Cisterna 4x2 400 HP Agua (5000 gal) [28.57 h]; CAPATAZ [2.86 h]; CUADRADOR/VIGÍA [28.57 h]; PEON [114.27 h]; Rodillo Vib. Liso Autopropulsado 135 HP 12 TM [28.57 h] |
| 2.05.11 |  | CODOS HDPE DE 14" DN 355mm | 1d | 2024-02-08 | 2024-02-08 | 2.05.06 | 10.33d | 0d | CAPATAZ [0.32 h]; OPERARIO [3.2 h]; PEON [9.6 h] |
| 2.05.07 |  | CONCRETO f'c=100 kg/cm2 | 1d | 2024-02-09 | 2024-02-09 | 2.05.11 | 10.33d | 0d | CAPATAZ [0.25 h]; OFICIAL [1.23 h]; OPERARIO [2.45 h]; PEON [12.27 h] |
| 2.05.10 |  | ACERO DE REFUERZO fy=4200 kg/cm2 | 0.67d | 2024-02-10 | 2024-02-10 | 2.05.07 | 10.33d | 0d | CAPATAZ [22.75 h]; OPERARIO [229.58 h]; PEON [229.58 h] |
| 2.05.09 |  | ENCOFRADO Y DESENCOFRADO RECTO | 1d | 2024-02-12 | 2024-02-12 | 2.05.10 | 10.33d | 0d | CAPATAZ [31.4 h]; OPERARIO [62.8 h]; PEON [62.8 h] |
| 2.05.08 |  | CONCRETO f'c=280 kg/cm2 | 1d | 2024-02-13 | 2024-02-13 | 2.05.09 | 10.33d | 0d | OFICIAL [122.05 h]; OPERARIO [61.02 h]; PEON [610.24 h] |
| 2.05.04 |  | RELLENO ESTRUCTURAL PARA OBRAS DE ARTE CON MATERIAL PROPIO | 1d | 2024-02-14 | 2024-02-14 | 2.05.08, 2.05.05 FF | 10.33d | 0d | CAPATAZ [0.47 h]; CUADRADOR/VIGÍA [4.66 h]; PEON [18.62 h] |

| ID | WBS | Activity | Duration | Start | Finish | Predecessors | Total float | Free float | Resources |
| --- | --- | --- | --- | --- | --- | --- | --- | --- | --- |
|  | 3 | **ARQUITECTURA Y PAISAJISMO** |  | 2024-02-20 | 2024-04-19 |  |  |  |  |
|  | 1 | **OBRAS PRELIMINARES** |  | 2024-02-20 | 2024-02-28 |  |  |  |  |
| 04.01.01 |  | MOVILIZACIÓN Y DEMOVILIZACIÓN DE EQUIPOS Y HERRAMIENTAS (ARQUITECTURA Y PAISAJISMO) | 1d | 2024-02-20 | 2024-02-20 | 2.05.04 FS+3.67d | 10.33d | 0d |  |
| 04.01.02 |  | TRAZO Y REPLANTEO PRELIMINAR | 6.67d | 2024-02-21 | 2024-02-28 | 04.01.01 | 10.33d | 0d | OPERARIO [55.06 h]; PEON [110.12 h]; TOPOGRAFO [55.06 h] |
|  | 2 | **MOVIMIENTO DE TIERRAS** |  | 2024-02-29 | 2024-03-12 |  |  |  |  |
| 04.02.01 |  | EXCAVACIÓN MANUAL PARA INSTALACIÓN DE BORDILLOS Y CIMENTACIONES | 1d | 2024-02-29 | 2024-02-29 | 04.01.02 | 10.33d | 0d | CAPATAZ [0.76 h]; PEON [7.57 h] |
| 04.02.02 |  | EXCAVACIÓN PARA MEJORAMIENTO DE SUELO CON TIERRA VEGETAL | 9.33d | 2024-02-29 | 2024-03-11 | 04.02.01 SS | 10.33d | 0d | CAPATAZ [7.86 h]; PEON [78.63 h] |
| 04.02.03 |  | ELIMINACION DE MATERIAL EXCEDENTE (DME´S) | 1d | 2024-03-12 | 2024-03-12 | 04.02.02 | 10.33d | 0d | Camión Volquete (15 m3) [0.74 h]; CAPATAZ [0.12 h]; Excavadora Sobre Oruga 260 HP [0.25 h]; OPERARIO [0.25 h]; PEON [1.49 h]; Tractor S/Orugas (D6T) - 180 HP [0.25 h] |
|  | 3 | **PAVIMENTOS, RECUBRIMIENTOS Y BORDILLOS** |  | 2024-03-13 | 2024-04-03 |  |  |  |  |
| 04.03.01 |  | PISO DE GRAVILLA | 1d | 2024-03-13 | 2024-03-13 | 04.02.03 | 10.33d | 0d | CAPATAZ [0.2 h]; OPERARIO [2 h]; PEON [3.99 h] |
| 04.03.02 |  | RECUBRIMIENTO DE PIEDRA DEL LUGAR e=0.05cm | 8.33d | 2024-03-14 | 2024-03-23 | 04.03.01 | 10.33d | 0d | CAPATAZ [6.52 h]; OFICIAL [130.46 h]; PEON [130.46 h] |
| 04.03.03 |  | BORDILLOS DE PIEDRA DEL LUGAR | 6.67d | 2024-03-25 | 2024-04-03 | 04.03.02 | 10.33d | 0d | CAPATAZ [4.96 h]; OFICIAL [99.2 h]; PEON [99.2 h] |
|  | 4 | **MOBILIARIOS, BARANDAS Y ESCALERAS** |  | 2024-04-04 | 2024-04-11 |  |  |  |  |
| 04.04.01 |  | ESCALERA DE CONCRETO SOBRE ENROCADO, CIMENTACION Y ANCLAJE | 1d | 2024-04-04 | 2024-04-04 | 04.03.03 | 10.33d | 0d |  |
| 04.04.02 |  | BARANDA DE MADERA EUCALIPTO CON SOGA, INCLUYE CIMENTACIÓN | 1d | 2024-04-04 | 2024-04-04 | 04.04.01 SS | 10.33d | 0d | CAPATAZ [0.36 h]; PEON [14.4 h] |
| 04.04.03 |  | TACHOS DE BASURA, INCLUYE CIMENTACIÓN | 1d | 2024-04-04 | 2024-04-04 | 04.04.01 SS, 04.04.02 SS | 10.33d | 0d |  |
| 04.04.04 |  | BANCAS DE CONCRETO, INCLUYE CIMENTACIÓN | 1d | 2024-04-05 | 2024-04-05 | 04.04.03 | 10.33d | 0d |  |
| 04.04.05 |  | POSTES DE ILUMINACIÓN, INCLUYE LUMINARIA Y CIMENTACIÓN | 3.89d | 2024-04-06 | 2024-04-10 | 04.04.04 | 10.33d | 0d | CAPATAZ [3.2 h]; OPERARIO [3.2 h]; PEON [64 h] |
| 04.04.07 |  | BOLARDOS DE PIEDRA | 3d | 2024-04-08 | 2024-04-10 | 04.04.05 SS+0.89d | 10.33d | 0d | CAPATAZ [2.4 h]; PEON [6 h] |
| 04.04.06 |  | SEÑALETICA INFORMATIVA | 1d | 2024-04-11 | 2024-04-11 | 04.04.05 | 17.67d |  |  |
|  | 5 | **OBRAS PRELIMINARES PAISAJISMO** |  | 2024-04-11 | 2024-04-16 |  |  |  |  |
| 04.05.01 |  | MEJORAMIENTO DE SUELO CON TIERRA DE CHACRA | 1d | 2024-04-11 | 2024-04-11 | 04.04.07 | 10.33d | 0d | OFICIAL [0.69 h]; PEON [5.5 h] |
| 04.05.02 |  | UBICACIÓN Y DELIMITACIÓN DE ZONA DE PLANTACIÓN | 1d | 2024-04-12 | 2024-04-12 | 04.05.01 | 10.33d | 0d | OFICIAL [2.04 h]; PEON [6.13 h] |
| 04.05.03 |  | DESPEDREGADO DEL TERRENO CON MEDIOS MANUALES | 0.67d | 2024-04-13 | 2024-04-13 | 04.05.02 | 10.33d | 0d | CAPATAZ [0.14 h]; PEON [5.5 h] |
| 04.05.04 |  | RASTRILLADO DEL TERRENO | 0.67d | 2024-04-13 | 2024-04-13 | 04.05.03 SS | 10.33d | 0d | CAPATAZ [0.11 h]; PEON [4.4 h] |
| 04.05.05 |  | TRAZADO, MARCACIÓN Y ESTACADO | 1d | 2024-04-15 | 2024-04-15 | 04.05.04 | 10.33d | 0d | PEON [0.55 h]; TOPOGRAFO [0.28 h] |
| 04.05.06 |  | RETIRO DE DESMONTE Y RESIDUOS SOLIDOS | 1d | 2024-04-16 | 2024-04-16 | 04.05.05 | 10.33d | 0d | CAPATAZ [0.05 h]; PEON [0.92 h] |

| ID | WBS | Activity | Duration | Start | Finish | Predecessors | Total float | Free float | Resources |
| --- | --- | --- | --- | --- | --- | --- | --- | --- | --- |
|  | 6 | **INSTALACION DE PLANTONES (Incluye colocación de sustrato, tierra del lugar, tutores y excavación)** |  | 2024-04-17 | 2024-04-18 |  |  |  |  |
| 04.10.01 |  | INST. PROSOPIS PALLIDA KUNTH ALGARROBO (0.80 a 1.50m) | 1d | 2024-04-17 | 2024-04-17 | 04.05.06 | 10.33d | 0d | OFICIAL [0 h]; PEON [0.08 h] |
| 04.10.02 |  | INST. ACACIA MACRACANTHA FAIQUE (0.80 a 1.50m) | 1d | 2024-04-17 | 2024-04-17 | 04.10.01 SS | 10.33d | 0d | OFICIAL [0.01 h]; PEON [0.24 h] |
| 04.10.03 |  | INST. PARKINSONIA ACULEATA AZOTE DE CRISTO (1.00 a 1.50 m) | 1d | 2024-04-17 | 2024-04-17 | 04.10.02 SS | 10.33d | 0d | OFICIAL [0.01 h]; PEON [0.24 h] |
| 04.10.04 |  | INST. SENNA MULTIGLANDULOSA MUTUY (0.60 a 0.80m) | 1d | 2024-04-17 | 2024-04-17 | 04.10.03 SS | 10.33d | 0d | OFICIAL [0.56 h]; PEON [11.12 h] |
| 04.10.05 |  | INST. ENCELIA CANESCEN GIRASOL SILVESTRE (0.20m a 0.30m) | 2d | 2024-04-17 | 2024-04-18 | 04.10.04 SS | 10.33d | 0d | OFICIAL [0.82 h]; PEON [16.48 h] |
|  | 7 | **INTALACIÓN DE ALCORQUES** |  | 2024-04-19 | 2024-04-19 |  |  |  |  |
| 04.11.01 |  | ALCORQUES DE PIEDRA DE CANTO RODADO PARA ARBOLES | 1d | 2024-04-19 | 2024-04-19 | 04.10.05 | 10.33d |  | CAPATAZ [0.02 h]; OFICIAL [0.2 h]; PEON [0.4 h] |
|  | 4 | **PROGRAMA DE CIERRE DE OBRA** |  | 2024-04-10 | 2024-05-04 |  |  |  |  |
| 5.012 |  | RESTAURACIÓN DE ÁREAS DE INSTALACIONES PROVISIONALES | 12d | 2024-04-10 | 2024-04-25 | 1.06.05.08 FS+4.65d, 2.02.01.02, 2.02.03.05, 2.02.05.02, 2.03.01.02, 2.03.03.02, 2.04.02.02.07 | 6.24d | 0d | Camión Cisterna 4x2 400 HP Agua (5000 gal) [2342.82 h]; CAPATAZ [2306.82 h]; CUADRADOR/VIGÍA [2302.82 h]; Motoniveladora 185 HP [40 h]; OPERARIO [2302.82 h]; PEON [2462.82 h]; Retroexcavador 58 HP [1138.47 h]; Rodillo Vib. Liso Autopropulsado 135 HP 12 TM [40 h]; Tractor S/Orugas (D6T) - 180 HP [2342.82 h] |
| 5.022 |  | DESMOVILIZACIÓN | 0.67d | 2024-05-04 | 2024-05-04 | 5.012, 1.06.02.05, 04.04.06 FF, 04.11.01, 1.01.03, 1.03.02.05, 1.03.03.01, 1.04.04, 1.05.01.05, 1.06.03, 1.06.03.05, 1.06.04.05, 1.06.05.05, 2.01.01.02, 2.01.03.05, 2.01.06.08 | 0d |  |  |
